Schedule from MS Project MPX, 2013-05-22 to 2015-03-13, A marks actual dates.

## Calendars

- Standard: Mon-Fri 08:00-12:00, 13:00-17:00; Sat-Sun off.

## Schedule

| ID | WBS | Task | Duration | Start | Finish | Predecessors | Resources |
| --- | --- | --- | --- | --- | --- | --- | --- |
| 1 | 1 | Idee | 0 | 2013-05-22 A |  |  | Max E.T. Schmidt |
| 2 | 2 | Idee schützen | 5 | 2013-05-22 A | 2013-05-28 | 1 | Max E.T. Schmidt; Vertragsanwälte |
| 3 | 3 | Kontaktpersonen suchen | 40 | 2013-05-29 A | 2013-07-23 | 2 | Max E.T. Schmidt |
| 4 | 4 | Verkauf der Idee an Produktionsfirma | 20 | 2013-07-24 A | 2013-08-20 | 3 | Max E.T. Schmidt; Vertragsanwälte |
| 5 | 5 | **Drehbucherstellung** | 105.000 | 2013-08-21 A | 2014-01-14 |  |  |
| 6 | 5.1 | Drehbuchautor aussuchen | 10 | 2013-08-21 A | 2013-09-03 | 4 | Produktionsteam |
| 7 | 5.2 | Vertrag mit Drehbuchautor | 5 | 2013-09-04 A | 2013-09-10 | 6 | Vertragsanwälte |
| 8 | 5.3 | Drehbuch schreiben | 60 | 2013-09-11 A | 2013-12-03 | 7 | Drehbuchautor |
| 9 | 6 | Regisseur suchen | 10 | 2013-08-21 A | 2013-09-03 | 4 | Produktionsteam |
| 10 | 7 | Teamplanung | 10 | 2013-09-04 A | 2013-09-17 | 9 | Regisseur |
| 11 | 8 | Storyboard | 60 | 2013-12-04 A | 2014-02-25 | 10, 8 | Storyboardzeichner |
| 12 | 9 | Locations festlegen | 40 | 2013-12-04 A | 2014-01-28 | 10, 8 | Locationscout |
| 13 | 10 | **Schauspieler casting** | 182.000 | 2013-09-04 A | 2014-05-15 |  |  |
| 14 | 10.1 | Hauptdarsteller | 10 | 2013-12-04 A | 2013-12-17 | 8, 9 | Produktionsteam; Regisseur[50%] |
| 15 | 10.2 | Nebendarsteller | 20 | 2013-12-04 A | 2013-12-31 | 9, 8 | Produktionsteam; Regisseur |
| 16 | 10.3 | Statisten | 10 | 2013-09-04 A | 2013-09-17 | 9 | Produktionsteam |
| 17 | 10.4 | Stuntmen | 5 | 2014-02-26 A | 2014-03-04 | 9, 11 | Produktionsteam; Regisseur[30%] |
| 18 | 11 | Besetzung abgeschlossen | 0 | 2014-03-05 A |  | 17, 16, 14, 15 |  |
| 19 | 12 | **Dreh** | 100 | 2014-03-05 A | 2014-07-22 |  |  |
| 20 | 12.1 | Innendrehs | 60 | 2014-03-05 A | 2014-05-27 | 18, 12 | Beleuchter; Bruder 2; Kameramann; Callgirl; männliche Hauptrolle; männlicher Gegenspieler; Maske; Obdachloser; Regieassistent; Regisseur; Statisten[20%]; Tontechniker; Kostüme; weibliche Hauptrolle |
| 21 | 12.2 | **Aussendrehs** | 16 | 2014-05-28 A | 2014-06-18 |  |  |
| 22 | 12.2.1 | Hubschrauberaufnahmen | 3 | 2014-05-28 A | 2014-05-30 | 12, 20 | Regisseur; Versicherung[1/Tag]; männliche Hauptrolle[10%]; Hubschrauberpaket[1]; Kameramann; Tontechniker; Regieassistent |
| 23 | 12.2.2 | Autoverfolgung | 4 | 2014-06-02 A | 2014-06-05 | 22, 17, 20 | Versicherung[1/Tag]; Regisseur; Regieassistent; Kameramann; Tontechniker; Beleuchter; Statisten[800%]; Autos[3/Tag]; Bruder 2[25%]; Callgirl[30%]; Stuntmen |
| 24 | 12.2.3 | Stunts | 3 | 2014-06-06 A | 2014-06-10 | 20, 17, 23 | Stuntmen; Regisseur; Kameramann; Beleuchter; Tontechniker; Regieassistent; Maske; Kostüme; Versicherung[2/Tag] |
| 25 | 12.2.4 | Schiffaufnahmen | 1 | 2014-06-11 A | 2014-06-11 | 24, 20, 18, 12 | Regisseur; Kameramann; Beleuchter; Tontechniker; Statisten[800%]; Maske; Kostüme |
| 26 | 12.2.5 | Schiffsexplosion | 1 | 2014-06-12 A | 2014-06-12 | 10, 25, 20 | Regisseur; Kameramann; Beleuchter; Tontechniker; Statisten; Regieassistent; 3-D-Leute; Versicherung[5] |
| 27 | 13 | Dreh abgeschlossen | 0 | 2014-06-13 A |  | 23, 22, 26, 20, 25, 24 |  |

Notes:
- 9: Gesamtkosten für den Regisseur
- 10: Kameramann, Musikautor, Schnitttechnik, Stunts, Specialeffect-Team, Maske, Kostüme...

| ID | WBS | Task | Duration | Start | Finish | Predecessors | Resources |
| --- | --- | --- | --- | --- | --- | --- | --- |
| 28 | 14 | **Postproduction** | 84 | 2014-06-13 A | 2014-10-08 |  |  |
| 29 | 14.1 | Schnitt | 40 | 2014-07-11 A | 2014-09-04 | 31, 30, 27 | Regisseur; Regieassistent; Cutter; Kameramann[50%] |
| 30 | 14.2 | Tonaufnahmen | 20 | 2014-06-13 A | 2014-07-10 | 27 | Regisseur[50%]; Regieassistent[50%]; Tontechniker; männliche Hauptrolle[10%]; weibliche Hauptrolle[10%]; Callgirl[10%]; Komponisten[80%] |
| 31 | 14.3 | Special Effects | 20 | 2014-06-13 A | 2014-07-10 | 27 | 3-D-Leute; Regisseur[50%]; Cutter; Regieassistent[50%] |
| 32 | 15 | Film fertig | 0 | 2014-09-05 A |  | 29 |  |
| 33 | 16 | **Marketing** | 196.000 | 2014-06-13 A | 2015-03-13 |  |  |
| 34 | 16.1 | Trailor | 4 | 2014-09-05 A | 2014-09-10 | 32 | Regisseur; Produktionsteam; Cutter; Tontechniker |
| 35 | 16.2 | Merchandising Produkte | 40 | 2014-06-13 A | 2014-08-07 | 27 |  |
| 36 | 16.3 | Buch zum Film | 60 | 2014-09-05 A | 2014-11-27 | 29 |  |
| 37 | 16.4 | CD/DVD/Video | 60 | 2014-09-05 A | 2014-11-27 | 32 |  |
| 38 | 16.5 | Pressetexte, Anzeigen, Plakate | 80 | 2014-09-05 A | 2014-12-25 | 32 |  |
| 39 | 16.6 | Fernseh- und Printinterviews | 40 | 2014-09-05 A | 2014-10-30 | 32 |  |
| 40 | 17 | Vorführung | 1 | 2014-12-26 A | 2014-12-26 | 37, 36, 34, 38, 35, 39 |  |
